# MARSWetNodeSim

Schedule from MS Project, 2007-03-15 to 2007-08-21.
mbari

## Calendars

- Standard: Mon-Fri 08:00-12:00, 13:00-17:00; Sat-Sun off.

## Resources

| Resource | Group |
| --- | --- |
| Brekke Knute | DMO |
| Conway Mike | DMO |
| Dawe Craig | DMO |
| Etchemendy Steve | DMO |
| Graves Dale | DMO |
| Massion Gene | R&D |
| Mellinger Ed | R&D |
| Osborne DJ | DMO |
| Talkovic Mark | DMO |
| Todd Carolyn | R&D |
| Littlefield Dick | R&D |
| Braccio Peter | OED |
| Sullivan Kevin | DMO |

## Schedule

| ID | WBS | Task | Type | Duration | Start | Finish | Predecessors | Total slack | Free slack | Constraint | Resources | Work |
| --- | --- | --- | --- | --- | --- | --- | --- | --- | --- | --- | --- | --- |
| 1 | 1 | Design Mechanicals | milestone | 0d | 2007-03-15 | 2007-03-15 |  | 14d | 0d |  |  |  |
| 2 | 2 | Design LV Card Cage |  | 15d | 2007-03-15 | 2007-04-04 | 1 | 14d | 0d |  | Talkovic Mark | 120h |
| 3 | 3 | Design/ Purchase PC104 Carrier/Mount |  | 4d | 2007-03-15 | 2007-03-20 | 1 | 106d | 11d |  | Dawe Craig | 32h |
| 4 | 4 | Design ODI Bottom Mount |  | 4d | 2007-03-15 | 2007-03-20 | 1 | 25d |  |  | Brekke Knute | 32h |
| 5 | 5 | Draw Rack Mount GA |  | 4d | 2007-04-05 | 2007-04-10 | 3, 2 | 95d |  |  | Brekke Knute | 32h |
| 6 | 6 | Design Power Interface |  | 4d? | 2007-03-15 | 2007-03-20 | 1 | 25d |  |  | Brekke Knute | 32h |
| 7 | 7 | Define Network Structure | milestone | 0d | 2007-03-15 | 2007-03-15 |  | 99d | 0d |  |  |  |
| 8 | 8 | Build Up PMACS Client |  | 5d | 2007-03-15 | 2007-03-21 | 7 | 102d | 0d |  | Dawe Craig | 40h |
| 9 | 9 | Build up PMACS Server |  | 5d | 2007-03-15 | 2007-03-21 | 7 | 99d | 0d |  | Dawe Craig; Braccio Peter | 80h |
| 10 | 10 | Build up NPC |  | 5d | 2007-03-28 | 2007-04-03 | 9, 11, 12, 13 | 99d | 0d |  | Sullivan Kevin | 40h |
| 11 | 11 | Configure Ciscos |  | 4d | 2007-03-22 | 2007-03-27 | 9 | 99d | 0d |  | Braccio Peter; Dawe Craig; Sullivan Kevin | 96h |
| 12 | 12 | Test Client |  | 1d | 2007-03-22 | 2007-03-22 | 8 | 102d | 3d |  | Braccio Peter; Dawe Craig; Sullivan Kevin | 24h |
| 13 | 13 | Test Server |  | 1d | 2007-03-22 | 2007-03-22 | 9 | 102d | 3d |  | Braccio Peter; Dawe Craig; Sullivan Kevin | 24h |
| 14 | 14 | Test NPC |  | 1d | 2007-04-04 | 2007-04-04 | 10 | 99d |  |  | Braccio Peter; Dawe Craig; Sullivan Kevin | 24h |
| 15 | 15 | Order Parts | milestone | 0d | 2007-04-05 | 2007-04-05 |  | 2d | 0d | finish no earlier than 2007-04-05 |  |  |
| 16 | 16 | Order ODI Connectors |  | 1d | 2007-04-06 | 2007-04-06 | 15 | 2d |  |  | Dawe Craig | 8h |
| 17 | 17 | Deilvery of ODI |  | 84d | 2007-04-25 | 2007-08-20 | 16, 25 | 0d |  |  |  |  |
| 18 | 18 | Order DB connectors |  | 1d | 2007-03-27 | 2007-03-27 | 22 | 0d |  |  | Dawe Craig | 8h |
| 19 | 19 | Order PC104 Cage |  | 1d | 2007-04-06 | 2007-04-06 | 15 | 87d |  |  | Dawe Craig | 8h |
| 20 | 20 | Order Power Connectors |  | 1d | 2007-04-06 | 2007-04-06 | 15 | 87d |  |  | Dawe Craig | 8h |
| 21 | 21 | Generate Wiring Diagrams | milestone | 0d | 2007-03-15 | 2007-03-15 |  | 0d |  |  |  |  |
| 22 | 22 | Generate wiring diagrams |  | 8d | 2007-03-15 | 2007-03-26 | 21 | 0d |  |  | Dawe Craig; Osborne DJ | 128h |
| 24 | 23 | Build wiring harness |  | 20d | 2007-03-28 | 2007-04-24 | 18 | 0d |  |  | Littlefield Dick; Sullivan Kevin; Todd Carolyn | 480h |
| 25 | 24 | Assemble MWNS | milestone | 0d | 2007-04-24 | 2007-04-24 | 4, 6, 2, 24 | 0d |  | start no earlier than 2007-04-02 |  |  |
| 26 | 25 | mount PCB rack |  | 1d | 2007-04-25 | 2007-04-25 | 25 | 79d | 0d |  | Talkovic Mark | 8h |
| 27 | 26 | Mount Cisco3750 |  | 1d | 2007-04-26 | 2007-04-26 | 26 | 79d | 0d |  | Talkovic Mark; Brekke Knute; Conway Mike | 24h |
| 28 | 27 | Mount PC104 |  | 1d | 2007-04-27 | 2007-04-27 | 27 | 79d | 0d |  | Brekke Knute; Conway Mike; Talkovic Mark | 24h |
| 29 | 28 | Mount PMACS Server |  | 1d | 2007-04-30 | 2007-04-30 | 28 | 79d | 0d |  | Brekke Knute; Conway Mike; Talkovic Mark | 24h |
| 30 | 29 | Install power bar |  | 1d | 2007-05-01 | 2007-05-01 | 29 | 79d | 0d |  | Brekke Knute; Conway Mike; Talkovic Mark | 24h |
| 31 | 30 | Install 480 3phase power |  | 1d | 2007-05-02 | 2007-05-02 | 30 | 79d |  |  | Brekke Knute; Conway Mike; Talkovic Mark | 24h |
| 32 | 31 | Install ODI cable |  | 1d | 2007-08-21 | 2007-08-21 | 17 | 0d |  |  | Brekke Knute; Conway Mike; Talkovic Mark | 24h |
| 33 | 32 | Develop Test and Qualifying Procedures |  | 6d | 2007-07-24 | 2007-07-31 | 25 | 5d |  | start no earlier than 2007-07-24 | Dawe Craig; Braccio Peter; Osborne DJ; Sullivan Kevin | 192h |
| 34 | 33 | PDR/CDR | milestone | 0d | 2007-03-30 | 2007-03-30 |  | 103d |  | start no earlier than 2007-03-30 |  |  |
